# Dorado2002revB

Schedule from MS Project, 2002-03-15 to 2003-02-06, A marks actual dates.
KEE Systems

## Calendars

- Standard: Mon-Fri 08:00-12:00, 13:00-17:00; Sat-Sun off.

## Resources

| Resource |
| --- |
| Hans |
| Drew |
| Sib |
| Farley |
| ME |
| Rob |
| Rich |
| Craig |
| Kent |
| ME TECH |
| EE TECH |
| Shop |
| Kiwi |

## Schedule

| ID | WBS | Task | Duration | Start | Finish | Predecessors | Remaining | Total slack | Free slack | Constraint | Resources | Work | Actual work |
| --- | --- | --- | --- | --- | --- | --- | --- | --- | --- | --- | --- | --- | --- |
| 1 | 1 | **Dorado Program** | 235d? | 2002-03-15 A | 2003-02-06 |  | 234.18d? | 0d |  |  |  | 15150.4h | 42.52h |
| 3 | 1.1 | **Propulsion** | 127d | 2002-03-15 | 2002-09-09 |  |  | 51d |  |  |  | 422h |  |
| 4 | 1.1.1 | **Articulated Tail** | 10d | 2002-03-15 | 2002-03-28 |  |  | 164d | 14d |  |  | 108h |  |
| 5 | 1.1.1.1 | Design & Build New Electronics Housing | 10d | 2002-03-15 | 2002-03-28 |  |  | 164d |  |  | Farley | 80h |  |
| 6 | 1.1.1.2 | New Linear Actuator Scheme | 7d | 2002-03-15 | 2002-03-25 |  |  | 167d |  |  | Hans [50%] | 28h |  |
| 7 | 1.1.2 | **Drive Electronics** | 24d | 2002-03-15 | 2002-04-17 |  |  | 148d | 0d |  |  | 136h |  |
| 8 | 1.1.2.1 | Integrate New Electroincs | 24d | 2002-03-15 | 2002-04-17 |  |  | 148d |  | start no earlier than 2002-03-15 | Sib [50%] | 96h |  |
| 9 | 1.1.2.2 | Cabling | 5d | 2002-03-28 | 2002-04-03 |  |  | 158d |  | start no earlier than 2002-03-28 | EE TECH | 40h |  |
| 10 | 1.1.3 | Integrate New Tail Into fairing | 5d | 2002-04-18 | 2002-04-24 | 7 |  | 148d | 0d |  | Farley | 40h |  |
| 11 | 1.1.4 | Tailcone - Bench Stand Design and Fab | 3d | 2002-03-15 | 2002-03-19 |  |  | 175d |  |  | ME TECH | 24h |  |
| 12 | 1.1.5 | Buoyancy Check / Test | 1d | 2002-04-25 | 2002-04-25 | 10 |  | 148d |  |  | Drew [25%] | 2h |  |
| 13 | 1.1.6 | Test Plan | 5d | 2002-04-08 | 2002-04-12 |  |  | 157d |  | start no earlier than 2002-04-08 | Rob | 40h |  |
| 14 | 1.1.7 | **Tailcone Documetation** | 103d | 2002-04-18 | 2002-09-09 | 7, 4 |  | 51d |  |  |  | 72h |  |
| 15 | 1.1.7.1 | Mechanical | 3d | 2002-04-18 | 2002-04-22 |  |  | 151d |  |  | Farley | 24h |  |
| 16 | 1.1.7.2 | Electrical | 2d | 2002-09-02 | 2002-09-03 |  |  | 55d |  | start no earlier than 2002-09-02 | Sib | 16h |  |
| 17 | 1.1.7.3 | Software | 4d | 2002-09-04 | 2002-09-09 |  |  | 51d |  | start no earlier than 2002-09-04 | Sib | 32h |  |
| 19 | 1.2 | **Power** | 49d? | 2002-03-15 | 2002-05-22 |  |  | 139d |  |  | Hans | 1717.2h |  |
| 20 | 1.2.1 | **Battery Chemistry** | 27d | 2002-03-15 | 2002-04-22 |  |  | 139d |  |  | Hans | 444h |  |
| 21 | 1.2.1.1 | Check life on current Ag-Zn batteries | 2d | 2002-03-15 | 2002-03-18 |  |  | 142d | 3d |  | Hans [50%] | 8h |  |
| 22 | 1.2.1.2 | Trade study to review Batt Chems | 2d | 2002-03-15 | 2002-03-18 |  |  | 142d | 3d |  | Hans [50%] | 8h |  |
| 23 | 1.2.1.3 | Thermal Analysis of Battery Pack | 5d | 2002-03-15 | 2002-03-21 |  |  | 139d | 0d |  | Kiwi | 40h |  |
| 24 | 1.2.1.4 | Design Review of Batt Chems | 1d | 2002-03-22 | 2002-03-22 | 21, 22, 23 |  | 139d | 0d |  | Hans | 8h |  |
| 25 | 1.2.1.5 | Purchase Batteries | 1d | 2002-03-25 | 2002-03-25 | 24 |  | 205d | 0d |  | Hans [50%] | 4h |  |
| 26 | 1.2.1.6 | Assemble Batteries | 5d | 2002-03-26 | 2002-04-01 | 25 |  | 205d | 0d |  | EE TECH | 40h |  |
| 27 | 1.2.1.7 | Test Batteries | 15d | 2002-04-02 | 2002-04-22 | 26 |  | 205d | 3d |  | EE TECH | 120h |  |

| ID | WBS | Task | Duration | Start | Finish | Predecessors | Total slack | Free slack | Constraint | Resources | Work |
| --- | --- | --- | --- | --- | --- | --- | --- | --- | --- | --- | --- |
| 28 | 1.2.2 | **Battery Housing** | 30d | 2002-03-25 | 2002-05-03 | 24 | 199d |  |  | Hans | 512h |
| 29 | 1.2.2.1 | Design | 10d | 2002-03-25 | 2002-04-05 |  | 199d | 0d |  | Craig | 80h |
| 30 | 1.2.2.2 | Build | 15d | 2002-04-08 | 2002-04-26 | 29 | 199d | 0d |  | ME TECH | 120h |
| 31 | 1.2.2.3 | Test | 5d | 2002-04-29 | 2002-05-03 | 30 | 199d |  |  | Craig | 40h |
| 32 | 1.2.2.4 | Spec Interconnects | 4d | 2002-03-25 | 2002-03-28 |  | 202d | 16d | finish no earlier than 2002-03-25 | Sib | 32h |
| 33 | 1.2.3 | **Battery Electronics** | 21d? | 2002-04-22 | 2002-05-20 | 24, 32 | 186d | 0d |  | Sib | 322h |
| 34 | 1.2.3.1 | Concept Design | 5d | 2002-04-22 | 2002-04-26 |  | 186d | 0d | start no earlier than 2002-04-22 | Sib | 40h |
| 35 | 1.2.3.2 | Design Review | 2d | 2002-04-29 | 2002-04-30 | 34 | 186d | 0d |  | Sib | 16h |
| 36 | 1.2.3.3 | Final Design | 11d | 2002-05-01 | 2002-05-15 | 35 | 186d | 0d | start no earlier than 2002-05-01 | Sib [75%] | 66h |
| 37 | 1.2.3.4 | Build | 1d | 2002-05-16 | 2002-05-16 | 36 | 186d | 0d |  | EE TECH | 8h |
| 38 | 1.2.3.5 | Assemble | 1d | 2002-05-17 | 2002-05-17 | 37 | 186d | 0d |  | EE TECH | 8h |
| 39 | 1.2.3.6 | Test | 1d | 2002-05-20 | 2002-05-20 | 38 | 186d |  |  | EE TECH | 8h |
| 40 | 1.2.3.7 | Spec Misc Electronics (Contingency) | 1d? | 2002-04-26 | 2002-04-26 | 27 | 202d |  | start no earlier than 2002-04-26 | Sib | 8h |
| 41 | 1.2.4 | **Battery Charging** | 2d | 2002-05-21 | 2002-05-22 | 24, 33 | 186d |  |  | Hans | 23.2h |
| 42 | 1.2.4.1 | Spec Charging Analysis | 2d | 2002-05-21 | 2002-05-22 |  | 186d |  |  | Hans [20%] | 3.2h |
| 43 | 1.2.4.2 | Order Charging Equip as Required | 1d | 2002-05-21 | 2002-05-21 |  | 187d |  |  | Hans [50%] | 4h |
| 44 | 1.2.5 | AUV Power Systems Meeting | 3d | 2002-04-26 | 2002-04-30 |  | 202d |  | start no earlier than 2002-04-26 | Hans | 24h |
| 46 | 1.3 | **Cabling and Connectors** | 24d | 2002-03-25 | 2002-04-25 | 24 | 148d |  |  | Drew | 364h |
| 47 | 1.3.1 | Spec Main Power / Comms Cable&Connectors/Penetrators | 13d | 2002-03-25 | 2002-04-10 |  | 148d | 0d |  | Hans [50%] | 52h |
| 48 | 1.3.2 | Spec Charging Connector | 4d | 2002-04-11 | 2002-04-16 | 47 | 155d |  |  | Hans [25%] | 8h |
| 49 | 1.3.3 | Spec Tailcone Comms Cable&Connector/Penetrator | 3d | 2002-03-25 | 2002-03-27 |  | 158d | 10d | start no earlier than 2002-03-18 | Sib | 24h |
| 50 | 1.3.4 | Spec Science Instrument Connector | 2d | 2002-03-25 | 2002-03-26 |  | 156d | 0d |  | Drew [25%] | 4h |
| 51 | 1.3.5 | Spec DVL and parosci Connectors / Penetrator | 1d | 2002-03-27 | 2002-03-27 | 50 | 156d | 0d |  | Drew [25%] | 2h |
| 52 | 1.3.6 | Spec RF/Acoustic/Emer location Connect & Penetrators | 1d | 2002-03-28 | 2002-03-28 | 51 | 156d | 0d |  | Drew [50%] | 4h |
| 53 | 1.3.7 | Spec On/Off Connector/Penetrator | 1d | 2002-03-29 | 2002-03-29 | 52 | 156d | 8d |  | Drew [25%] | 2h |
| 54 | 1.3.8 | Test ability of 100 MB/s thrugh current ALTEX Cable | 2d | 2002-03-25 | 2002-03-26 |  | 170d |  |  | Drew | 16h |
| 55 | 1.3.9 | Order Connectors | 1d | 2002-04-11 | 2002-04-11 | 47, 49, 53 | 148d | 0d |  | Drew | 8h |

| ID | WBS | Task | Duration | Start | Finish | Predecessors | Complete | Remaining | Total slack | Free slack | Constraint | Resources | Work | Actual work |
| --- | --- | --- | --- | --- | --- | --- | --- | --- | --- | --- | --- | --- | --- | --- |
| 56 | 1.3.10 | **Tail to MVC** | 1d | 2002-03-25 | 2002-03-25 |  |  |  | 161d |  |  | Drew | 12h |  |
| 57 | 1.3.10.1 | Section Interconnect | 1d | 2002-03-25 | 2002-03-25 |  |  |  | 161d | 13d |  | Drew [50%] | 4h |  |
| 58 | 1.3.11 | Documetation package on Connectors and Cabling | 10d | 2002-04-12 | 2002-04-25 | 55, 57 |  |  | 148d |  |  | Drew [50%] | 40h |  |
| 60 | 1.4 | **Main Vehicle Computer** | 39d | 2002-03-15 A | 2002-05-08 |  | 3% | 37.95d | 139d |  |  | Sib | 1924h | 42.52h |
| 61 | 1.4.1 | **Electronics** | 29d | 2002-03-15 A | 2002-04-24 |  | 4% | 27.74d | 149d |  |  | Sib | 996h | 34.09h |
| 62 | 1.4.1.1 | Spec PC 104 Stack | 2d | 2002-03-15 A | 2002-03-18 A |  | 100% |  |  |  |  | Sib | 16h | 16h |
| 63 | 1.4.1.2 | Order PC 104 Stack | 1d | 2002-03-19 A | 2002-03-19 A | 62 | 100% |  |  |  |  | Sib | 8h | 8h |
| 64 | 1.4.1.3 | Assemble PC 104 Stack | 2d | 2002-03-20 | 2002-03-21 | 63 |  |  | 173d |  |  | EE TECH | 16h |  |
| 65 | 1.4.1.4 | Develop latency test/budget for MVC | 4d | 2002-04-11 | 2002-04-16 |  |  |  | 155d |  | finish no earlier than 2002-04-16 | Sib [50%] | 16h |  |
| 66 | 1.4.1.5 | **Power Board** | 23d | 2002-03-25 | 2002-04-24 | 24 |  |  | 139d | 0d |  | Sib | 322h |  |
| 67 | 1.4.1.5.1 | Specify | 4d | 2002-03-25 | 2002-03-28 |  |  |  | 139d | 0d |  | Sib [50%] | 16h |  |
| 68 | 1.4.1.5.2 | Design | 15d | 2002-03-29 | 2002-04-18 | 67 |  |  | 139d | 0d |  | Sib [75%] | 90h |  |
| 69 | 1.4.1.5.3 | Order | 1d | 2002-04-19 | 2002-04-19 | 68 |  |  | 139d | 0d |  | Sib | 8h |  |
| 70 | 1.4.1.5.4 | Build | 2d | 2002-04-22 | 2002-04-23 | 69 |  |  | 139d | 0d |  | EE TECH | 16h |  |
| 71 | 1.4.1.5.5 | Test | 1d | 2002-04-24 | 2002-04-24 | 70 |  |  | 139d |  |  | EE TECH | 8h |  |
| 72 | 1.4.1.6 | **RF Modem** | 6d | 2002-03-15 | 2002-03-22 |  |  |  | 172d |  |  | Drew | 70h |  |
| 73 | 1.4.1.6.1 | Evaluate Data-link vs Freewave | 5d | 2002-03-15 | 2002-03-21 |  |  |  | 172d | 0d |  | Drew [50%] | 20h |  |
| 74 | 1.4.1.6.2 | Purchase | 1d | 2002-03-22 | 2002-03-22 | 73 |  |  | 172d |  |  | Drew [25%] | 2h |  |
| 75 | 1.4.1.7 | **Acoustic Modem** | 2d | 2002-03-15 | 2002-03-18 |  |  |  | 166d | 27d |  | Hans | 24h |  |
| 76 | 1.4.1.7.1 | Evaluate | 1d | 2002-03-15 | 2002-03-15 |  |  |  | 166d | 0d |  | Hans [50%] | 4h |  |
| 77 | 1.4.1.7.2 | Purchase | 1d | 2002-03-18 | 2002-03-18 | 76 |  |  | 166d |  |  | Hans [50%] | 4h |  |
| 78 | 1.4.1.8 | **GPS** | 15d | 2002-03-15 | 2002-04-04 |  |  |  | 153d | 14d |  | Drew | 234h |  |
| 79 | 1.4.1.8.1 | Evaluate GPS Position Fix Problem | 10d | 2002-03-15 | 2002-03-28 |  |  |  | 153d | 0d |  | Craig | 80h |  |
| 80 | 1.4.1.8.2 | Evaluate GPS Board & Antennae | 4d | 2002-03-29 | 2002-04-03 | 79 |  |  | 153d | 0d |  | Craig | 32h |  |
| 81 | 1.4.1.8.3 | Purchase GPS Board & Antennae | 1d | 2002-04-04 | 2002-04-04 | 80 |  |  | 153d |  |  | Drew [25%] | 2h |  |
| 82 | 1.4.1.9 | Eval and Purchase 10/100 Hub | 4d | 2002-03-20 | 2002-03-25 |  |  |  | 171d |  | start no earlier than 2002-03-20 | Sib [25%] | 8h |  |
| 83 | 1.4.1.10 | Eval & Purchase AHRS | 1d | 2002-03-15 | 2002-03-15 |  |  |  | 177d |  |  | Drew [25%] | 2h |  |
| 84 | 1.4.1.11 | Eval and Purchase LBL Board Set | 4d | 2002-03-15 | 2002-03-20 |  |  |  | 174d |  |  | Hans [25%] | 8h |  |
| 85 | 1.4.1.12 | Spec and Purcahse DVL | 5d | 2002-03-15 | 2002-03-21 |  |  |  | 173d |  |  | Rob | 40h |  |

| ID | WBS | Task | Duration | Start | Finish | Predecessors | Total slack | Free slack | Constraint | Resources | Work |
| --- | --- | --- | --- | --- | --- | --- | --- | --- | --- | --- | --- |
| 86 | 1.4.2 | **MVC Housing** | 28d | 2002-03-15 | 2002-04-23 |  | 140d |  |  | Drew | 424h |
| 87 | 1.4.2.1 | Spec Interconnects | 6d | 2002-03-15 | 2002-03-22 |  | 140d | 0d |  | Drew [50%] | 24h |
| 88 | 1.4.2.2 | Design | 5d | 2002-03-25 | 2002-03-29 | 87 | 140d | 0d |  | Farley | 40h |
| 89 | 1.4.2.3 | Build/Purchase | 10d | 2002-04-01 | 2002-04-12 | 88 | 140d | 0d |  | Shop | 80h |
| 90 | 1.4.2.4 | Pressure Test | 2d | 2002-04-15 | 2002-04-16 | 89 | 140d | 0d |  | ME TECH | 16h |
| 91 | 1.4.2.5 | Electronics Packagin Layout | 5d | 2002-04-17 | 2002-04-23 | 90 | 140d | 1d |  | Drew | 40h |
| 92 | 1.4.3 | **Documentation Package** | 10d | 2002-04-25 | 2002-05-08 | 91, 78, 75, 66 | 139d |  |  | Sib | 192h |
| 93 | 1.4.3.1 | Mechanical | 2d | 2002-04-25 | 2002-04-26 |  | 145d | 6d |  | Farley | 16h |
| 94 | 1.4.3.2 | Electrical | 8d | 2002-04-25 | 2002-05-06 |  | 139d | 0d |  | Sib | 64h |
| 95 | 1.4.3.3 | Software | 2d | 2002-04-25 | 2002-04-26 |  | 145d | 6d |  | Hans | 16h |
| 96 | 1.4.3.4 | Integration | 2d | 2002-05-07 | 2002-05-08 | 94, 95, 93 | 139d |  |  | Sib | 16h |
| 98 | 1.5 | **Navigation Hardware & Testing** | 53d | 2002-03-15 | 2002-05-28 |  | 125d |  |  | Hans | 1159.2h |
| 99 | 1.5.1 | **Deep Water testing of USBL** | 38d | 2002-03-15 | 2002-05-07 |  | 125d | 0d |  | Hans | 467.2h |
| 100 | 1.5.1.1 | Tank testing | 18d | 2002-03-15 | 2002-04-09 |  | 125d | 0d |  | Hans [30%] | 43.2h |
| 101 | 1.5.1.2 | At Sea Testing | 20d | 2002-04-10 | 2002-05-07 | 100 | 125d |  |  | Hans [75%] | 120h |
| 102 | 1.5.2 | **Deep Water Testing of LBL Fish Mode** | 15d | 2002-05-08 | 2002-05-28 | 99 | 125d |  |  | Hans | 240h |
| 103 | 1.5.2.1 | Tank Testing | 10d | 2002-05-08 | 2002-05-21 |  | 125d | 0d |  | Hans | 80h |
| 104 | 1.5.2.2 | At Sea Testing | 5d | 2002-05-22 | 2002-05-28 | 103 | 125d |  |  | Hans | 40h |
| 105 | 1.5.3 | Radio Range for modems | 3d | 2002-03-15 | 2002-03-19 |  | 175d |  |  | Drew [50%] | 12h |
| 106 | 1.5.4 | RDF Ranging | 3d | 2002-03-15 | 2002-03-19 |  | 174d | 0d |  | Drew [50%] | 12h |
| 107 | 1.5.5 | Eval Zephyr RDF capability | 1d | 2002-03-20 | 2002-03-20 | 106 | 174d |  |  | Drew [50%] | 4h |
| 109 | 1.6 | **Fairings / Vehicle Mechanical Structure** | 52d | 2002-03-15 | 2002-05-27 |  | 126d |  |  | Drew | 2504h |
| 110 | 1.6.1 | **L&R System Interface** | 36d | 2002-03-15 | 2002-05-03 |  | 142d |  |  | Drew | 632h |
| 111 | 1.6.1.1 | Prelim Concept w/ Brook ocean | 5d | 2002-03-15 | 2002-03-21 |  | 142d | 0d |  | Farley | 40h |
| 112 | 1.6.1.2 | Concept Design Review / Decision | 1d | 2002-03-22 | 2002-03-22 | 111 | 142d | 0d |  | Farley | 8h |
| 113 | 1.6.1.3 | Design L&R Interface | 10d | 2002-03-25 | 2002-04-05 | 112 | 142d | 0d |  | Farley | 80h |
| 114 | 1.6.1.4 | Build Interface | 10d | 2002-04-08 | 2002-04-19 | 113 | 142d | 0d |  | Shop | 80h |
| 115 | 1.6.1.5 | Assemble Interface | 5d | 2002-04-22 | 2002-04-26 | 114 | 142d | 0d |  | ME TECH | 40h |
| 116 | 1.6.1.6 | L&R test plan | 4d | 2002-03-15 | 2002-03-20 |  | 169d | 27d |  | Drew | 32h |
| 117 | 1.6.1.7 | Integrate and Test L&R Interface | 5d | 2002-04-29 | 2002-05-03 | 116, 115 | 142d |  |  | Farley | 40h |
| 118 | 1.6.1.8 | Evaluate Single Point lift | 3d | 2002-03-26 | 2002-03-28 |  | 168d |  | start no earlier than 2002-03-26 | Drew | 24h |

| ID | WBS | Task | Duration | Start | Finish | Predecessors | Total slack | Free slack | Constraint | Resources | Work |
| --- | --- | --- | --- | --- | --- | --- | --- | --- | --- | --- | --- |
| 119 | 1.6.2 | **Joining Ring/Systems** | 34d | 2002-03-15 | 2002-05-01 |  | 126d | 0d |  | Drew | 568h |
| 120 | 1.6.2.1 | Evaluate joining ring systems | 2d | 2002-03-15 | 2002-03-18 |  | 126d | 0d |  | Farley | 16h |
| 121 | 1.6.2.2 | Review Concept | 1d | 2002-03-19 | 2002-03-19 | 120 | 126d | 0d |  | Farley | 8h |
| 122 | 1.6.2.3 | Final Design | 15d | 2002-03-20 | 2002-04-09 | 121 | 126d | 0d |  | Farley | 120h |
| 123 | 1.6.2.4 | Build | 10d | 2002-04-10 | 2002-04-23 | 122 | 126d | 0d |  | Shop | 80h |
| 124 | 1.6.2.5 | Assemble | 3d | 2002-04-24 | 2002-04-26 | 123 | 126d | 0d |  | ME TECH | 24h |
| 125 | 1.6.2.6 | Test | 3d | 2002-04-29 | 2002-05-01 | 124 | 126d |  |  | Drew | 24h |
| 126 | 1.6.2.7 | Test new joining ring system | 3d | 2002-04-04 | 2002-04-08 |  | 143d |  | start no earlier than 2002-04-04 | Drew | 24h |
| 127 | 1.6.3 | **Deck Handling Equipment** | 10d | 2002-05-14 | 2002-05-27 | 141 | 126d |  |  | Drew | 336h |
| 128 | 1.6.3.1 | New Cart Design | 5d | 2002-05-14 | 2002-05-20 |  | 131d |  |  | ME TECH | 40h |
| 129 | 1.6.3.2 | New Lifitng Gear | 5d | 2002-05-14 | 2002-05-20 |  | 131d |  |  | ME TECH | 40h |
| 130 | 1.6.3.3 | Sphere Lift Mechanism | 10d | 2002-05-14 | 2002-05-27 |  | 126d |  |  | Farley | 80h |
| 131 | 1.6.3.4 | Eval Single Pt. Lift | 2d | 2002-05-14 | 2002-05-15 |  | 134d |  |  | Drew | 16h |
| 132 | 1.6.3.5 | Lifting I beam in Lab | 5d | 2002-05-14 | 2002-05-20 |  | 131d |  |  | ME TECH | 40h |
| 133 | 1.6.3.6 | Cable trays nad outlets in lab ceiling | 5d | 2002-05-14 | 2002-05-20 |  | 131d |  |  | ME TECH | 40h |
| 134 | 1.6.4 | **Sensor & Payload Mounts** | 4d | 2002-03-15 | 2002-03-20 |  | 156d | 30d |  | Drew | 96h |
| 135 | 1.6.4.1 | Antennaes | 4d | 2002-03-15 | 2002-03-20 |  | 156d |  |  | Drew | 32h |
| 136 | 1.6.4.2 | ORE & various equip | 4d | 2002-03-15 | 2002-03-20 |  | 156d |  |  | Drew | 32h |
| 137 | 1.6.5 | **Buoyancy** | 10d | 2002-03-15 | 2002-03-28 |  | 150d | 24d |  | Drew | 200h |
| 138 | 1.6.5.1 | Tailcone Foam Pack Specification | 5d | 2002-03-15 | 2002-03-21 |  | 150d | 0d |  | Farley | 40h |
| 139 | 1.6.5.2 | Tailcone foam machining | 5d | 2002-03-22 | 2002-03-28 | 138 | 150d |  |  | Farley | 40h |
| 140 | 1.6.5.3 | Modular trim / ballast systems concept | 5d | 2002-03-15 | 2002-03-21 |  | 155d |  |  | Rob | 40h |
| 141 | 1.6.6 | **Fairing Build** | 8d | 2002-05-02 | 2002-05-13 | 134, 137, 119 | 126d | 0d |  | Drew | 256h |
| 142 | 1.6.6.1 | Noes section (2 plus 1 spare) | 8d | 2002-05-02 | 2002-05-13 |  | 126d |  |  | ME TECH | 64h |
| 143 | 1.6.6.2 | Midboady (2 plus 1 spare) | 8d | 2002-05-02 | 2002-05-13 |  | 126d |  |  | ME TECH | 64h |
| 144 | 1.6.6.3 | Tail section (2 plus 1 spare) | 8d | 2002-05-02 | 2002-05-13 |  | 126d |  |  | ME TECH | 64h |

| ID | WBS | Task | Duration | Start | Finish | Predecessors | Total slack | Free slack | Constraint | Resources | Work |
| --- | --- | --- | --- | --- | --- | --- | --- | --- | --- | --- | --- |
| 146 | 1.7 | **Software** | 178d | 2002-03-15 | 2002-11-19 |  | 0d |  |  | Hans | 3924h |
| 147 | 1.7.1 | Change supervisor so drivers run all the time | 3d | 2002-09-02 | 2002-09-04 |  | 50d | 0d | start no earlier than 2002-09-02 | Hans [50%] | 12h |
| 148 | 1.7.2 | Chang logging to convert files to MATLAB | 4d | 2002-09-05 | 2002-09-10 | 147 | 50d |  |  | Hans [50%] | 16h |
| 149 | 1.7.3 | **OS Upgrade** | 6d | 2002-03-15 | 2002-03-22 |  | 172d |  |  | Sib | 96h |
| 150 | 1.7.3.1 | QNX Upgrade to Neutrino | 3d | 2002-03-15 | 2002-03-19 |  | 172d | 0d |  | Kent | 24h |
| 151 | 1.7.3.2 | Eval Linux for possible upgrade in future | 3d | 2002-03-20 | 2002-03-22 | 150 | 172d |  |  | Kent | 24h |
| 152 | 1.7.4 | **GUI** | 50d | 2002-03-15 | 2002-05-23 |  | 128d |  |  | Rich | 800h |
| 153 | 1.7.4.1 | gather requirements | 5d | 2002-03-15 | 2002-03-21 |  | 128d | 0d |  | Rich | 40h |
| 154 | 1.7.4.2 | eval Bluefin GUI | 10d | 2002-03-22 | 2002-04-04 | 153 | 128d | 0d |  | Rich | 80h |
| 155 | 1.7.4.3 | develop GUI plan | 5d | 2002-04-05 | 2002-04-11 | 154 | 128d | 0d |  | Rich | 40h |
| 156 | 1.7.4.4 | Detail GUI development (TBD) | 30d | 2002-04-12 | 2002-05-23 | 155 | 128d |  |  | Rich | 240h |
| 157 | 1.7.5 | Configuration management on vehicle (config files) | 15d | 2002-03-15 | 2002-04-04 |  | 163d |  |  | Rich | 120h |
| 158 | 1.7.6 | **Controls** | 45d | 2002-03-15 | 2002-05-16 |  | 133d |  |  | Rob | 720h |
| 159 | 1.7.6.1 | depth control improvement (long configs) | 15d | 2002-03-15 | 2002-04-04 |  | 133d | 0d |  | Rob | 120h |
| 160 | 1.7.6.2 | sway / yaw control coupling (heave/ pitch too) | 10d | 2002-04-05 | 2002-04-18 | 159 | 133d | 0d |  | Rob | 80h |
| 161 | 1.7.6.3 | slow speed dynamics for control | 20d | 2002-04-19 | 2002-05-16 | 160 | 133d |  |  | Rob | 160h |
| 162 | 1.7.7 | **Navigation Software** | 42d | 2002-09-23 | 2002-11-19 |  | 0d |  |  | Hans | 684h |
| 163 | 1.7.7.1 | Document current NAV sys | 4d | 2002-09-23 | 2002-09-26 |  | 0d |  | start no earlier than 2002-09-23 | Hans [50%] | 16h |
| 164 | 1.7.7.2 | Streamline current nav architecture | 8d | 2002-09-27 | 2002-10-08 | 163 | 0d |  |  | Hans [50%] | 32h |
| 165 | 1.7.7.3 | Single beacon homing | 15d | 2002-10-09 | 2002-10-29 | 164 | 0d |  |  | Hans [50%] | 60h |
| 166 | 1.7.7.4 | Single beacon LBL | 15d | 2002-10-30 | 2002-11-19 | 165 | 0d |  |  | Hans | 120h |
| 167 | 1.7.7.5 | DVL driver enhancements for PD5 | 15d | 2002-10-09 | 2002-10-29 | 164 | 15d |  |  | Rob | 120h |
| 168 | 1.7.8 | **Intra-vehicle Comms** | 4d | 2002-10-01 | 2002-10-04 |  | 32d |  |  | Sib | 52h |
| 169 | 1.7.8.1 | set up socket code (for reconnects) | 3d | 2002-10-01 | 2002-10-03 |  | 32d | 0d | start no earlier than 2002-10-01 | Hans [50%] | 12h |
| 170 | 1.7.8.2 | briding over wireless | 1d | 2002-10-04 | 2002-10-04 | 169 | 32d |  |  | Sib | 8h |

| ID | WBS | Task | Duration | Start | Finish | Predecessors | Total slack | Free slack | Constraint | Resources | Work |
| --- | --- | --- | --- | --- | --- | --- | --- | --- | --- | --- | --- |
| 172 | 1.8 | **Vehicle Integration and Test** | 35d | 2002-11-20 | 2003-01-07 | 3, 46, 109, 60, 98, 146 | 0d |  |  | Hans | 584h |
| 173 | 1.8.1 | Tailcone Assembly | 5d | 2002-11-20 | 2002-11-26 |  | 5d | 0d |  | Hans [50%] | 20h |
| 174 | 1.8.2 | Tailcone Test | 4d | 2002-11-27 | 2002-12-02 | 173 | 5d |  |  | Sib [50%] | 16h |
| 175 | 1.8.3 | Battery Midbody Integration | 5d | 2002-11-20 | 2002-11-26 |  | 5d | 0d |  | Hans [50%] | 20h |
| 176 | 1.8.4 | Battery Midbody Test | 4d | 2002-11-27 | 2002-12-02 | 175 | 5d |  |  | Sib [50%] | 16h |
| 177 | 1.8.5 | ALTEX Nose Payload Assembly/Upgrade | 5d | 2002-11-20 | 2002-11-26 |  | 0d |  |  | Drew | 40h |
| 178 | 1.8.6 | Science Payload Assembly | 6d | 2002-11-27 | 2002-12-04 | 177 | 0d |  | start no earlier than 2002-06-07 |  |  |
| 179 | 1.8.7 | Payload Test | 3d | 2002-12-05 | 2002-12-09 | 178 | 0d |  |  | Drew | 24h |
| 180 | 1.8.8 | Integrated Vehcile Deck Assembly | 2d | 2002-12-10 | 2002-12-11 | 174, 176, 179 | 0d |  |  | Drew | 16h |
| 181 | 1.8.9 | Vehicle Ballasting | 1d | 2002-12-12 | 2002-12-12 | 180 | 0d |  |  | Drew | 8h |
| 182 | 1.8.10 | Integrated Vehicle Deck Test | 3d | 2002-12-13 | 2002-12-17 | 181 | 0d |  |  | Drew | 24h |
| 183 | 1.8.11 | Integrated Vehicle Tank Test | 5d | 2002-12-18 | 2002-12-24 | 182 | 0d |  |  | Drew | 40h |
| 184 | 1.8.12 | Integrated Vehicle Sea Trials | 10d | 2002-12-25 | 2003-01-07 | 183 | 0d |  |  | Drew | 80h |
| 186 | 1.9 | **CTD Science Payload Core** | 214d? | 2002-03-15 | 2003-01-08 |  | 21d |  |  | Drew | 1952h |
| 187 | 1.9.1 | Repair/Replace nose fairing | 3d | 2002-03-15 | 2002-03-19 |  | 175d | 0d |  | ME TECH | 24h |
| 188 | 1.9.2 | recable Dcon to comms and pwr bus | 8d | 2002-03-15 | 2002-03-26 |  | 151d | 0d |  | EE TECH | 64h |
| 189 | 1.9.3 | Design HS2 Mount | 2d | 2002-03-20 | 2002-03-21 | 187 | 175d | 0d |  | ME TECH | 16h |
| 190 | 1.9.4 | Build HS2 Mount | 2d | 2002-03-22 | 2002-03-25 | 189 | 175d | 0d |  | ME TECH | 16h |
| 191 | 1.9.5 | Assembly HS2 Mount | 2d | 2002-03-26 | 2002-03-27 | 190 | 175d |  |  | ME TECH | 16h |
| 192 | 1.9.6 | Write test driver HS2 | 5d | 2002-03-15 | 2002-03-21 |  | 179d |  |  | Rich | 40h |
| 193 | 1.9.7 | Eval Foam buoyancy cooridnate 1500 M version | 5d | 2002-03-15 | 2002-03-21 |  | 179d |  |  | Farley | 40h |
| 194 | 1.9.8 | repair flow sensor #2 | 3d | 2002-03-27 | 2002-03-29 | 188 | 151d |  |  | EE TECH | 24h |
| 195 | 1.9.9 | test integrated CTD Payload | 1d? | 2003-01-08 | 2003-01-08 | 194, 172 | 0d |  |  |  |  |
| 197 | 1.10 | **CTD Extension for Ryan/Haddock** | 21d | 2003-01-09 | 2003-02-06 | 194, 146, 195 | 0d |  |  | Drew | 488h |
| 198 | 1.10.1 | Design LISST pump assy | 4d | 2003-01-09 | 2003-01-14 |  | 0d |  |  | Drew [50%] | 16h |
| 199 | 1.10.2 | Fab LISST pump assy | 5d | 2003-01-15 | 2003-01-21 | 198 | 3d | 0d |  | Shop | 40h |
| 200 | 1.10.3 | Assy LISST pump into vehicle | 2d | 2003-01-22 | 2003-01-23 | 199 | 3d |  |  | ME TECH | 16h |
| 201 | 1.10.4 | Design LISST mount | 5d | 2003-01-15 | 2003-01-21 | 198 | 0d |  |  | Farley | 40h |
| 202 | 1.10.5 | Fab LISST Mount | 5d | 2003-01-22 | 2003-01-28 | 201 | 0d |  |  | Shop | 40h |
| 203 | 1.10.6 | Assy LISST mount | 2d | 2003-01-29 | 2003-01-30 | 200, 202 | 0d |  |  | ME TECH | 16h |
| 204 | 1.10.7 | Cable LISST to Dcon | 1d | 2003-01-31 | 2003-01-31 | 203 | 4d |  |  | EE TECH | 8h |
| 205 | 1.10.8 | Write Test Driver for LISST | 5d | 2003-01-31 | 2003-02-06 | 203 | 0d |  |  | Rich | 40h |
| 206 | 1.10.9 | Design Bathypho mount | 4d | 2003-01-09 | 2003-01-14 |  | 6d | 0d |  | Drew [50%] | 16h |
| 207 | 1.10.10 | Fab Bathypho mount | 5d | 2003-01-15 | 2003-01-21 | 206 | 6d | 0d |  | ME TECH | 40h |
| 208 | 1.10.11 | Assy Bathypho mount | 2d | 2003-01-22 | 2003-01-23 | 207 | 6d | 0d |  | ME TECH | 16h |
| 209 | 1.10.12 | Cable Bathypho to Dcon | 1d | 2003-01-24 | 2003-01-24 | 208 | 6d | 0d |  | EE TECH | 8h |
| 210 | 1.10.13 | Retest driver for Bathypho (already written) | 3d | 2003-01-27 | 2003-01-29 | 209 | 6d |  |  | Rich | 24h |
| 212 | 1.11 | Ryan / Haddock Cruise Prep | 14d | 2002-08-15 | 2002-09-03 |  | 112d |  | start no earlier than 2002-08-15 | Hans | 112h |
